# Zmiana lokalu

Schedule from MS Project, 2003-11-12 to 2004-01-02, status date 2003-11-12.
Doom

## Calendars

- Standardowy: Mon-Fri 08:00-12:00, 13:00-17:00; Sat-Sun off.

## Schedule

| ID | WBS | Task | Type | Duration | Start | Finish | Predecessors | Total slack | Free slack |
| --- | --- | --- | --- | --- | --- | --- | --- | --- | --- |
| 1 | 1 | start | milestone | 0d | 2003-11-12 08:00 | 2003-11-12 08:00 |  | 37.56d |  |
| 2 | 2 | **poszukiwanie lokalu** |  | 8.5d? | 2003-11-12 08:00 | 2003-11-24 12:00 |  | 0d |  |
| 3 | 2.1 | okreslanie potrzeb |  | 1d | 2003-11-12 08:00 | 2003-11-12 17:00 |  | 0d |  |
| 4 | 2.2 | przygotowanie ogloszenia |  | 0.5d | 2003-11-13 08:00 | 2003-11-13 12:00 | 3 | 0d |  |
| 5 | 2.3 | emisja ogloszenia | milestone | 0d | 2003-11-13 12:00 | 2003-11-13 12:00 | 4 | 0d |  |
| 6 | 2.4 | **rozpatrywanie ofert** |  | 6.5d? | 2003-11-13 13:00 | 2003-11-21 17:00 |  | 0d |  |
| 7 | 2.4.1 | **ocena ofert** |  | 5.5d? | 2003-11-13 13:00 | 2003-11-20 17:00 |  | 0d |  |
| 8 | 2.4.1.1 | definiowanie kryteriow oceny |  | 0.5d | 2003-11-13 13:00 | 2003-11-13 17:00 | 4 | 0d |  |
| 9 | 2.4.1.2 | wpisywanie zgloszonych ofert |  | 1d? | 2003-11-14 08:00 | 2003-11-14 17:00 | 8, 5 | 0d |  |
| 10 | 2.4.1.3 | wizyty w lokalach |  | 3d? | 2003-11-17 08:00 | 2003-11-19 17:00 | 9 | 0d |  |
| 11 | 2.4.1.4 | przypisywanie ocen |  | 1d | 2003-11-20 08:00 | 2003-11-20 17:00 | 10 | 0d |  |
| 12 | 2.4.2 | spisywanie i zebranie ocen |  | 1d | 2003-11-21 08:00 | 2003-11-21 17:00 | 11 | 0d |  |
| 13 | 2.5 | wybor lokalu | milestone | 0d | 2003-11-21 17:00 | 2003-11-21 17:00 | 12 | 0d |  |
| 14 | 2.6 | wyslanie powiadomien o decyzji |  | 0.5d | 2003-11-24 08:00 | 2003-11-24 12:00 | 13 | 0d |  |
| 15 | 3 | **przygotowanie do przeprowadzki** |  | 26d? | 2003-11-24 13:00 | 2003-12-30 12:00 |  | 0d |  |
| 16 | 3.1 | opiniowanie umowy |  | 2d | 2003-11-24 13:00 | 2003-11-26 12:00 | 14 | 0d |  |
| 17 | 3.2 | podpisanie umowy |  | 2h | 2003-11-26 13:00 | 2003-11-26 15:00 | 16 | 0d |  |
| 18 | 3.3 | wypowiedzenie umowy |  | 1h | 2003-11-26 15:00 | 2003-11-26 16:00 | 17 | 26.69d |  |
| 19 | 3.4 | zdanie lokalu |  | 0.5d? | 2003-12-30 08:00 | 2003-12-30 12:00 | 26 | 3.06d |  |
| 20 | 3.5 | ustalenie terminu przeprowadzki |  | 0.5d? | 2003-11-26 15:00 | 2003-11-27 10:00 | 17 | 18.5d | 0d |
| 21 | 3.6 | aranzacja wnetrz |  | 1mo | 2003-11-26 15:00 | 2003-12-24 15:00 | 17 | 0d |  |
| 22 | 4 | **przeprowadzka** |  | 26.31d? | 2003-11-27 10:00 | 2004-01-02 13:30 |  | 0d |  |
| 23 | 4.1 | poszukiwanie srodka transportu |  | 1d? | 2003-11-27 10:00 | 2003-11-28 10:00 | 20 | 18.5d |  |
| 24 | 4.2 | odebranie lokalu |  | 1d | 2003-12-24 15:00 | 2003-12-25 15:00 | 21, 23 | 0d |  |
| 25 | 4.3 | pakowanie wyposarzenia |  | 2d | 2003-12-25 15:00 | 2003-12-29 15:00 | 21, 24 | 0d |  |
| 26 | 4.4 | wynoszenie wyposarzenia |  | 2h | 2003-12-29 15:00 | 2003-12-29 17:00 | 25 | 0d |  |
| 27 | 4.5 | zaladunek |  | 1h | 2003-12-30 08:00 | 2003-12-30 09:00 | 26 | 0d |  |
| 28 | 4.6 | transport |  | 0.5h | 2003-12-30 09:00 | 2003-12-30 09:30 | 27 | 0d |  |
| 29 | 4.7 | wyladunek |  | 1h | 2003-12-30 09:30 | 2003-12-30 10:30 | 28 | 0d |  |
| 30 | 4.8 | wnoszenie wyposazenia |  | 2h | 2003-12-30 10:30 | 2003-12-30 13:30 | 29 | 0d |  |
| 31 | 4.9 | rozlokowanie spretu |  | 2d | 2003-12-30 13:30 | 2004-01-01 13:30 | 30 | 0d |  |
| 32 | 4.10 | rozlokowanie wyposarzenia |  | 2d | 2003-12-30 13:30 | 2004-01-01 13:30 | 30 | 0d |  |
| 33 | 4.11 | sprzatanie |  | 1d | 2004-01-01 13:30 | 2004-01-02 13:30 | 31, 32 | 0d |  |
| 34 | 5 | koniec | milestone | 0d | 2004-01-02 13:30 | 2004-01-02 13:30 | 19, 33 | 0d |  |
