# Zmiana lokalu

Schedule from MS Project, 2003-11-12 to 2004-01-01, status date 2003-11-12, costs in zł.
Doom

## Calendars

- Standardowy: Mon-Fri 08:00-12:00, 13:00-17:00; Sat-Sun off.

## Resources

| Resource | Group | Unit | Rate |
| --- | --- | --- | --- |
| Prezes | Administracja |  | 4800 |
| Asystentka prezesa | Administracja |  |  |
| Grafik | Firma Zew |  | 60 |
| Administrator budynku | Sluzba pomocnicza |  | 15 |
| Sekretarka | Administracja |  | 12 |
| Prawnik | Firma Zewnętrzna |  |  |
| Firma budowlana | Firma zewnętrzna |  |  |
| Pracownik pomocniczy | Pracownicy fizyczni |  | 8 |
| Firma transportowa | Firma Zewnętrzna |  |  |
| Informatyk | Sluzba pomocnicza |  | 20 |
| Elektryk | Pracownicy fizyczni |  | 10 |
| Komputer | Sprzet bourowy |  | 3 |
| Sprzataczka | Sluzba pomocnicza |  | 6 |
| Samochod | Transport |  | 10 |
| Paliwo | inne | litr | 3.34 |
| Moduł ogłoszeniowy | inne | modul | 180 |
| Pojemnik | Sprzet biurowy | sztuka | 15 |

## Schedule

| ID | WBS | Task | Type | Duration | Start | Finish | Predecessors | Total slack | Free slack | Resources | Work | Cost |
| --- | --- | --- | --- | --- | --- | --- | --- | --- | --- | --- | --- | --- |
| 1 | 1 | start | milestone | 0d | 2003-11-12 08:00 | 2003-11-12 08:00 |  | 36.15d |  |  |  |  |
| 2 | 2 | **poszukiwanie lokalu** |  | 7.58d? | 2003-11-12 08:00 | 2003-11-21 13:40 |  | 0d |  |  | 108h | 3,160 |
| 3 | 2.1 | okreslanie potrzeb |  | 0.33d | 2003-11-12 08:00 | 2003-11-12 10:40 |  | 0d |  | Administrator budynku; Prezes; Asystentka prezesa | 8h | 360 |
| 4 | 2.2 | przygotowanie ogloszenia |  | 0.25d | 2003-11-12 10:40 | 2003-11-12 13:40 | 3 | 0d |  | Grafik; Komputer | 4h | 126 |
| 5 | 2.3 | emisja ogloszenia |  | 1d | 2003-11-12 13:40 | 2003-11-13 13:40 | 4 | 0d |  | Moduł ogłoszeniowy [3.5 modul] |  | 630 |
| 6 | 2.4 | **rozpatrywanie ofert** |  | 6.5d? | 2003-11-12 13:40 | 2003-11-21 08:40 |  | 0d |  |  | 92h | 1,776 |
| 7 | 2.4.1 | **ocena ofert** |  | 5.5d? | 2003-11-12 13:40 | 2003-11-20 08:40 |  | 0d |  |  | 76h | 1,592 |
| 8 | 2.4.1.1 | definiowanie kryteriow oceny |  | 0.17d | 2003-11-12 13:40 | 2003-11-12 15:00 | 4 | 0.83d |  | Prezes; Asystentka prezesa; Administrator budynku | 4h | 180 |
| 9 | 2.4.1.2 | wpisywanie zgloszonych ofert |  | 0.5d? | 2003-11-13 13:40 | 2003-11-14 08:40 | 8, 5 | 0d |  | Asystentka prezesa; Komputer | 8h | 92 |
| 10 | 2.4.1.3 | wizyty w lokalach |  | 3d? | 2003-11-14 08:40 | 2003-11-19 08:40 | 9 | 0d |  | Asystentka prezesa; Administrator budynku | 48h | 890 |
| 11 | 2.4.1.4 | przypisywanie ocen |  | 1d | 2003-11-19 08:40 | 2003-11-20 08:40 | 10 | 0d |  | Asystentka prezesa; Administrator budynku | 16h | 280 |
| 12 | 2.4.2 | spisywanie i zebranie ocen |  | 1d | 2003-11-20 08:40 | 2003-11-21 08:40 | 11 | 0d |  | Asystentka prezesa; Komputer | 16h | 184 |
| 13 | 2.5 | wybor lokalu | milestone | 0d | 2003-11-21 08:40 | 2003-11-21 08:40 | 12 | 0d |  |  |  |  |
| 14 | 2.6 | wyslanie powiadomien o decyzji |  | 0.5d | 2003-11-21 08:40 | 2003-11-21 13:40 | 13 | 0d |  | Sekretarka | 4h | 68 |
| 15 | 3 | **przygotowanie do przeprowadzki** |  | 25.25d? | 2003-11-21 13:40 | 2003-12-26 15:40 |  | 0d |  |  | 251h | 4,220 |
| 16 | 3.1 | opiniowanie umowy |  | 2d | 2003-11-21 13:40 | 2003-11-25 13:40 | 14 | 0d |  | Prawnik | 16h |  |
| 17 | 3.2 | podpisanie umowy |  | 2h | 2003-11-25 13:40 | 2003-11-25 15:40 | 16 | 0d |  | Prezes | 2h | 200 |
| 18 | 3.3 | wypowiedzenie umowy |  | 1h | 2003-11-25 15:40 | 2003-11-25 16:40 | 17 | 26.19d |  | Prezes | 1h | 100 |
| 19 | 3.4 | zdanie lokalu |  | 0.25d? | 2003-12-26 13:40 | 2003-12-26 15:40 | 26 | 3.31d |  | Prezes; Administrator budynku | 4h | 530 |
| 20 | 3.5 | ustalenie terminu przeprowadzki |  | 0.25d? | 2003-11-25 15:40 | 2003-11-26 08:40 | 17 | 18.75d | 0d | Asystentka prezesa; Administrator budynku | 4h | 70 |
| 21 | 3.6 | aranzacja wnetrz |  | 1mo | 2003-11-25 15:40 | 2003-12-23 15:40 | 17 | 0d |  | Firma budowlana; Asystentka prezesa [20%]; Administrator budynku [20%] | 224h | 2,120 |
| 22 | 4 | **przeprowadzka** |  | 26.06d? | 2003-11-26 08:40 | 2004-01-01 09:10 |  | 0d |  |  | 194.5h | 2,968 |
| 23 | 4.1 | poszukiwanie srodka transportu |  | 1d? | 2003-11-26 08:40 | 2003-11-27 08:40 | 20 | 18.75d |  | Sekretarka | 8h | 116 |
| 24 | 4.2 | odebranie lokalu |  | 0.5d | 2003-12-23 15:40 | 2003-12-24 10:40 | 21, 23 | 0d |  | Prezes; Administrator budynku | 8h | 460 |
| 25 | 4.3 | pakowanie wyposarzenia |  | 2d | 2003-12-24 10:40 | 2003-12-26 10:40 | 21, 24 | 0d |  | Pracownik pomocniczy [300%] | 48h | 434 |
| 26 | 4.4 | wynoszenie wyposarzenia |  | 2h | 2003-12-26 10:40 | 2003-12-26 13:40 | 25 | 0d |  | Pracownik pomocniczy [300%] | 6h | 48 |
| 27 | 4.5 | zaladunek |  | 1h | 2003-12-26 13:40 | 2003-12-26 14:40 | 26 | 0d |  | Pracownik pomocniczy [300%] | 3h | 24 |
| 28 | 4.6 | transport |  | 0.5h | 2003-12-26 14:40 | 2003-12-26 15:10 | 27 | 0d |  | Firma transportowa | 0.5h |  |
| 29 | 4.7 | wyladunek |  | 1h | 2003-12-26 15:10 | 2003-12-26 16:10 | 28 | 0d |  | Pracownik pomocniczy [300%] | 3h | 24 |
| 30 | 4.8 | wnoszenie wyposazenia |  | 2h | 2003-12-26 16:10 | 2003-12-29 09:10 | 29 | 0d |  | Pracownik pomocniczy [300%] | 6h | 48 |
| 31 | 4.9 | rozlokowanie sprzetu |  | 2d | 2003-12-29 09:10 | 2003-12-31 09:10 | 30 | 0d |  |  |  | 80 |
| 32 | 4.10 | rozlokowanie wyposarzenia |  | 2d | 2003-12-29 09:10 | 2003-12-31 09:10 | 30 | 0d |  | Pracownik pomocniczy [300%]; Elektryk; Informatyk | 80h | 864 |
| 33 | 4.11 | sprzatanie |  | 1d | 2003-12-31 09:10 | 2004-01-01 09:10 | 31, 32 | 0d |  | Pracownik pomocniczy [300%]; Sprzataczka | 32h | 270 |
| 34 | 5 | koniec | milestone | 0d | 2004-01-01 09:10 | 2004-01-01 09:10 | 19, 33 | 0d |  |  |  |  |
